# Project_LSS3_ENCV_20180919

Schedule from MS Project, 2019-04-08 to 2019-08-30.
CERN

## Calendars

- Standard: Mon-Fri 08:00-12:00, 13:00-17:00; Sat-Sun off.

## Resources

| Resource |
| --- |
| RAM POWER |
| ? |
| OUVAROFF |
| TBD |

## Schedule

| ID | WBS | Task | Type | Duration | Start | Finish | Predecessors | Total slack | Resources | Work | Text1 |
| --- | --- | --- | --- | --- | --- | --- | --- | --- | --- | --- | --- |
| 1 | 1 | Echafaudage | manual | 5d | 2019-04-08 | 2019-04-15 | 2SF |  | OUVAROFF | 40h |  |
| 2 | 2 | Demontage | manual | 20d | 2019-04-15 | 2019-05-13 | 4SF |  | TBD | 160h | Idealement 25 jours. Attente contractant Nov18 |
| 3 | 3 | **Montage** |  | 80d | 2019-05-13 | 2019-08-30 |  | 0d | RAM POWER | 640h |  |
| 4 | 3.1 | montage LSS3- | manual | 15d | 2019-05-13 | 2019-05-31 |  |  |  |  | incl. 100 m DN150/200 |
| 5 | 3.2 | montage LSS3 caverne | manual | 15d | 2019-06-03 | 2019-06-21 | 4 |  |  |  | incl. 65 m DN150/200 |
| 6 | 3.3 | montage LSS3+ | manual | 40d | 2019-06-24 | 2019-08-16 | 5 |  |  |  | incl. 320 m DN150/200 |
| 7 | 3.4 | montage TA | manual | 5d | 2019-08-19 | 2019-08-23 | 6 |  |  |  |  |
| 8 | 3.5 | reparations + test pression | manual | 5d | 2019-08-26 | 2019-08-30 | 7 |  |  |  |  |
